# DESOx_A.2_Příloha_HMG

Schedule from MS Project, 2017-05-19 to 2022-10-02.
CHEMING, a.s.

## Calendars

- Standardní: Mon-Fri 09:00-13:00, 14:00-18:00; Sat-Sun off. Exceptions (off unless hours are given): 2018-03-31 09:00-13:00, 14:00-18:00, 2018-07-01 09:00-13:00, 14:00-18:00, 2018-12-22 09:00-13:00, 14:00-18:00, 2019-06-01 09:00-13:00, 14:00-18:00, 2019-08-24 09:00-13:00, 14:00-18:00.

## Schedule

| ID | WBS | Task | Type | Duration | Start | Finish | Predecessors | Total slack | Free slack | Constraint |
| --- | --- | --- | --- | --- | --- | --- | --- | --- | --- | --- |
| 1 | 1 | **Harmonogram / Time schedule** |  | 1406d | 2017-05-19 | 2022-10-02 |  | 0d |  |  |
| 2 | 1.1 | Výběrové řízení / Tender Procedure |  | 240d | 2017-05-19 | 2018-04-18 |  | 1081d | 0d | start no earlier than 2017-05-19 |
| 3 | 1.2 | Podpis smlouvy o dílo / Contract | milestone | 0d | 2018-04-18 | 2018-04-18 | 2 | 1081d | 0d |  |
| 4 | 1.3 | Předání Plánu jakosti / Quality manual hand over hand over | milestone | 0d | 2018-05-03 | 2018-05-03 | 3FS+15ed | 1155d |  |  |
| 5 | 1.4 | Příprava dokumentací BD, DD / Documentation - BD, DD prepartion |  | 120ed | 2018-04-18 | 2018-08-16 | 3 | 4522.88d |  |  |
| 6 | 1.5 | **Odlučovače - mezisilo popílku / Precipitators - intermediate fly ash silo** |  | 723d | 2018-07-01 | 2021-04-02 |  | 391d |  |  |
| 7 | 1.5.1 | Předání staveniště / Site hand over | milestone | 0d | 2018-07-01 | 2018-07-01 |  | 410d | 0d | start no earlier than 2018-07-01 |
| 8 | 1.5.2 | Montážní práce / Installation works |  | 244ed | 2018-07-01 | 2019-03-02 | 7 | 1644d | 0d |  |
| 9 | 1.5.3 | Komplexní zkoušky / Complex Tests |  | 14ed | 2019-03-02 | 2019-03-16 | 8 | 1644d | 0d |  |
| 10 | 1.5.4 | Uvádění do Provozu / Commissioning |  | 17ed | 2019-03-16 | 2019-04-02 | 9 | 1644d | 0d |  |
| 11 | 1.5.5 | Předběžné převzetí / Preliminary Acceptance | milestone | 0d | 2019-04-02 | 2019-04-02 | 10 | 394d | 0d |  |
| 12 | 1.5.6 | Konečné převzetí / Final Acceptance | milestone | 0d | 2021-04-02 | 2021-04-02 | 11FS+731ed | 391d |  |  |
| 13 | 1.6 | **Přeložky pro odlučovač O1 a O4 / Relocation for precipitator O1 and O4** |  | 145d | 2018-07-01 | 2019-01-17 |  | 969d |  |  |
| 14 | 1.6.1 | Předání staveniště / Site hand over | milestone | 0d | 2018-07-01 | 2018-07-01 | 7 | 964d | 0d |  |
| 15 | 1.6.2 | Přeložky pro odlučovač OK1 a OK4 / Relocation for precipitator OK1 and OK4 |  | 200ed | 2018-07-01 | 2019-01-17 | 14 | 4062d |  |  |
| 16 | 1.7 | **Kotel + Odlučovač K1 / Boiler + Precipitator K1** |  | 653d | 2020-04-01 | 2022-10-02 |  | 0d |  |  |
| 17 | 1.7.1 | Předání staveniště / Site hand over | milestone | 0d | 2020-04-01 | 2020-04-01 |  | 0d |  | start no earlier than 2020-04-01 |
| 18 | 1.7.2 | Montážní práce / Installation works |  | 122ed | 2020-04-01 | 2020-08-01 | 17 | 0d |  |  |
| 19 | 1.7.3 | Komplexní zkoušky / Complex Tests |  | 21ed | 2020-08-01 | 2020-08-22 | 18 | 0d |  |  |
| 20 | 1.7.4 | Uvádění do Provozu / Commissioning |  | 40ed | 2020-08-22 | 2020-10-01 | 19 | 0d |  |  |
| 21 | 1.7.5 | Předběžné převzetí / Preliminary Acceptance | milestone | 0d | 2020-10-01 | 2020-10-01 | 20 | 0d |  |  |
| 22 | 1.7.6 | Konečné převzetí / Final Acceptance | milestone | 0d | 2022-10-02 | 2022-10-02 | 21FS+731ed | 0d |  |  |
| 23 | 1.8 | **Kotel K2 / Boiler K2** |  | 565d | 2020-05-01 | 2022-07-01 |  | 66d |  |  |
| 24 | 1.8.1 | Předání staveniště / Site hand over | milestone | 0d | 2020-05-01 | 2020-05-01 |  | 66d | 0d | start no earlier than 2020-05-01 |
| 25 | 1.8.2 | Montážní práce / Installation works |  | 27ed | 2020-05-01 | 2020-05-28 | 24 | 279d | 0d |  |
| 26 | 1.8.3 | Komplexní zkoušky / Complex Tests |  | 3ed | 2020-05-28 | 2020-05-31 | 25 | 279d | 0d |  |
| 27 | 1.8.4 | Uvádění do Provozu / Commissioning |  | 30ed | 2020-05-31 | 2020-06-30 | 26 | 279d | 0d |  |
| 28 | 1.8.5 | Předběžné převzetí / Preliminary Acceptance | milestone | 0d | 2020-06-30 | 2020-06-30 | 27 | 67d | 0d |  |
| 29 | 1.8.6 | Konečné převzetí / Final Acceptance | milestone | 0d | 2022-07-01 | 2022-07-01 | 28FS+731ed | 66d |  |  |

| ID | WBS | Task | Type | Duration | Start | Finish | Predecessors | Total slack | Free slack | Constraint |
| --- | --- | --- | --- | --- | --- | --- | --- | --- | --- | --- |
| 30 | 1.9 | **Kotel / Boiler K3** |  | 565d | 2020-06-01 | 2022-08-01 |  | 45d |  |  |
| 31 | 1.9.1 | Předání staveniště / Site hand over | milestone | 0d | 2020-06-01 | 2020-06-01 |  | 45d | 0d | start no earlier than 2020-06-01 |
| 32 | 1.9.2 | Montážní práce / Installation works |  | 27ed | 2020-06-01 | 2020-06-28 | 31 | 186d | 0d |  |
| 33 | 1.9.3 | Komplexní zkoušky / Complex Tests |  | 3ed | 2020-06-28 | 2020-07-01 | 32 | 186d | 0d |  |
| 34 | 1.9.4 | Uvádění do Provozu / Commissioning |  | 30ed | 2020-07-01 | 2020-07-31 | 33 | 186d | 0d |  |
| 35 | 1.9.5 | Předběžné převzetí / Preliminary Acceptance | milestone | 0d | 2020-07-31 | 2020-07-31 | 34 | 44d | 0d |  |
| 36 | 1.9.6 | Konečné převzetí / Final Acceptance | milestone | 0d | 2022-08-01 | 2022-08-01 | 35FS+731ed | 45d |  |  |
| 37 | 1.10 | **Linka odsíření č.3 / Desulfurisation unit No. 3** |  | 928d | 2019-01-14 | 2022-08-01 |  | 44d |  |  |
| 38 | 1.10.1 | Předání staveniště / Site hand over | milestone | 0d | 2019-01-14 | 2019-01-14 |  | 972d | 0d | start no earlier than 2019-01-14 |
| 39 | 1.10.2 | Montážní práce před odstávkou / Installation works before shutdown |  | 60ed | 2020-03-02 | 2020-05-01 | 40SF | 2652d |  |  |
| 40 | 1.10.3 | Odstávka / Shutdown |  | 61ed | 2020-05-01 | 2020-07-01 |  | 183d | 0d | start no earlier than 2020-05-01 |
| 41 | 1.10.4 | Uvádění do Provozu / Commissioning |  | 23d | 2020-07-01 | 2020-07-31 | 40 | 43d | 0d |  |
| 42 | 1.10.5 | Předběžné převzetí / Preliminary Acceptance | milestone | 0d | 2020-07-31 | 2020-07-31 | 41 | 43d | 0d |  |
| 43 | 1.10.6 | Konečné převzetí / Final Acceptance | milestone | 0d | 2022-08-01 | 2022-08-01 | 42FS+731ed | 44d |  |  |
| 44 | 1.11 | **Kotel + Odlučovač K4 / Boiler + Precipitator K4** |  | 656d | 2019-04-01 | 2021-09-30 |  | 261d |  |  |
| 45 | 1.11.1 | Předání staveniště / Site hand over | milestone | 0d | 2019-04-01 | 2019-04-01 |  | 917d |  | start no earlier than 2019-04-01 |
| 46 | 1.11.2 | Montážní práce / Installation works |  | 90d | 2019-04-01 | 2019-08-01 |  | 263d | 0d | start no earlier than 2019-04-01 |
| 47 | 1.11.3 | Komplexní zkoušky / Complex Tests |  | 15d | 2019-08-02 | 2019-08-22 | 46 | 263d | 1d |  |
| 48 | 1.11.4 | Uvádění do Provozu / Commissioning |  | 26d | 2019-08-24 | 2019-09-27 | 47 | 262d | 0d | start no earlier than 2019-08-24 |
| 49 | 1.11.5 | Předběžné převzetí / Preliminary Acceptance |  | 1d | 2019-09-30 | 2019-09-30 | 48 | 262d | 0d |  |
| 50 | 1.11.6 | Konečné převzetí / Final Acceptance | milestone | 0d | 2021-09-30 | 2021-09-30 | 49FS+731ed | 261d |  |  |
| 51 | 1.12 | **Kotel / Boiler K5** |  | 567d | 2019-05-01 | 2021-06-30 |  | 328d |  |  |
| 52 | 1.12.1 | Předání staveniště / Site hand over | milestone | 0d | 2019-05-01 | 2019-05-01 |  | 330d | 0d | start no earlier than 2019-05-01 |
| 53 | 1.12.2 | Montážní práce / Installation works |  | 27ed | 2019-05-01 | 2019-05-28 | 52 | 1377d | 0d |  |
| 54 | 1.12.3 | Komplexní zkoušky / Complex Tests |  | 3ed | 2019-05-28 | 2019-05-31 | 53 | 1377d | 0d |  |
| 55 | 1.12.4 | Uvádění do Provozu / Commissioning |  | 30ed | 2019-05-31 | 2019-06-30 | 54 | 1377d | 0d |  |
| 56 | 1.12.5 | Předběžné převzetí / Preliminary Acceptance | milestone | 0d | 2019-06-30 | 2019-06-30 | 55 | 329d | 0d |  |
| 57 | 1.12.6 | Konečné převzetí / Final Acceptance | milestone | 0d | 2021-06-30 | 2021-06-30 | 56FS+731ed | 328d |  |  |

| ID | WBS | Task | Type | Duration | Start | Finish | Predecessors | Total slack | Free slack | Constraint |
| --- | --- | --- | --- | --- | --- | --- | --- | --- | --- | --- |
| 58 | 1.13 | **Kotel / Boiler K6** |  | 567d | 2019-06-01 | 2021-07-31 |  | 305d |  |  |
| 59 | 1.13.1 | Předání staveniště / Site hand over | milestone | 0d | 2019-06-01 | 2019-06-01 |  | 307d | 0d | start no earlier than 2019-06-01 |
| 60 | 1.13.2 | Montážní práce / Installation works |  | 27ed | 2019-06-01 | 2019-06-28 | 59 | 1284d | 0d |  |
| 61 | 1.13.3 | Komplexní zkoušky / Complex Tests |  | 3ed | 2019-06-28 | 2019-07-01 | 60 | 1284d | 0d |  |
| 62 | 1.13.4 | Uvádění do Provozu / Commissioning |  | 30ed | 2019-07-01 | 2019-07-31 | 61 | 1284d | 0d |  |
| 63 | 1.13.5 | Předběžné převzetí / Preliminary Acceptance | milestone | 0d | 2019-07-31 | 2019-07-31 | 62 | 307d | 0d |  |
| 64 | 1.13.6 | Konečné převzetí / Final Acceptance | milestone | 0d | 2021-07-31 | 2021-07-31 | 63FS+731ed | 305d |  |  |
| 65 | 1.14 | **Linka odsíření č.4 / Desulfurisation unit No. 4** |  | 667d | 2019-01-14 | 2021-08-01 |  | 305d |  |  |
| 66 | 1.14.1 | Předání staveniště / Site hand over | milestone | 0d | 2019-01-14 | 2019-01-14 | 38SS | 972d |  |  |
| 67 | 1.14.2 | Montážní práce před odstávkou / Installation works before shutdown |  | 60ed | 2019-03-02 | 2019-05-01 | 68SF | 3750d |  |  |
| 68 | 1.14.3 | Odstávka / Shutdown |  | 61ed | 2019-05-01 | 2019-07-01 |  | 1272d | 0d | start no earlier than 2019-05-01 |
| 69 | 1.14.4 | Uvádění do Provozu / Commissioning |  | 23d | 2019-07-01 | 2019-07-31 | 68 | 305d | 0d |  |
| 70 | 1.14.5 | Předběžné převzetí / Preliminary Acceptance | milestone | 0d | 2019-08-01 | 2019-08-01 | 69FS+1d | 305d | 0d |  |
| 71 | 1.14.6 | Konečné převzetí / Final Acceptance | milestone | 0d | 2021-08-01 | 2021-08-01 | 70FS+731ed | 305d |  |  |
